# proyecto1-modificado

Schedule from MS Project, 2008-09-30 to 2008-12-04.
_

## Calendars

- Estándar: Mon off; Tue 09:25-11:10, 11:40-13:25; Wed off; Thu 10:20-11:10, 11:40-14:20; Fri-Sun off. Exceptions (off unless hours are given): 2008-10-13, 2008-10-27, 2008-10-31, 2008-12-01.
- Calendario de clase: Mon off; Tue 09:25-11:10, 11:40-13:25; Wed off; Thu 10:20-11:10, 11:40-14:20; Fri-Sun off. Exceptions (off unless hours are given): 2008-10-13, 2008-10-27, 2008-10-31, 2008-12-01.

## Resources

| Resource |
| --- |
| profesor |
| técnico DPE |
| laboratorio |

## Schedule

| ID | WBS | Task | Duration | Start | Finish | Predecessors | Baseline start | Baseline finish | Baseline duration | Total slack | Free slack | Calendar | Resources | Work |
| --- | --- | --- | --- | --- | --- | --- | --- | --- | --- | --- | --- | --- | --- | --- |
| 1 | 1 | presentación | 1h | 2008-09-30 | 2008-09-30 |  | 2008-09-30 | 2008-09-30 | 1h | 0d |  | Calendario de clase | profesor; laboratorio | 1h |
| 2 | 2 | **estudios previos** | 3d | 2008-09-30 | 2008-10-23 |  | 2008-09-30 | 2008-10-23 | 3.12d | 0d |  | Calendario de clase |  | 28h |
| 3 | 2.1 | Repaso del PIC16F84 | 5h | 2008-09-30 | 2008-10-02 | 1 | 2008-09-30 | 2008-10-02 | 5h | 0d |  | Calendario de clase | profesor | 5h |
| 4 | 2.2 | Proteus | 4h | 2008-10-02 | 2008-10-07 | 3 | 2008-10-07 | 2008-10-09 | 4h | 0d |  | Calendario de clase | profesor; técnico DPE | 8h |
| 5 | 2.3 | práctica PIC16F84 | 4h | 2008-10-07 | 2008-10-09 | 4 | 2008-10-09 | 2008-10-14 | 4h | 1.5d |  | Calendario de clase | profesor | 4h |
| 6 | 2.4 | estudio del PIC16F88 | 4h | 2008-10-07 | 2008-10-16 | 4 | 2008-10-09 | 2008-10-16 | 4h | 0d |  | Calendario de clase | profesor | 4h |
| 7 | 2.5 | estudio de MS-Project | 2h | 2008-10-21 | 2008-10-23 | 8 | 2008-10-21 | 2008-10-23 | 2h | 5.62d |  | Calendario de clase | profesor | 2h |
| 8 | 2.6 | estudio de la gestión de proyectos | 4h | 2008-10-16 | 2008-10-21 | 9 | 2008-10-16 | 2008-10-21 | 4h | 5.62d | 0d | Calendario de clase | profesor | 4h |
| 9 | 2.7 | estudio de la conversión A/D | 1h | 2008-10-16 | 2008-10-16 | 6 | 2008-10-16 | 2008-10-16 | 1h | 5.62d | 0d | Calendario de clase | profesor | 1h |
| 10 | 3 | **realización del hardware** | 5.25d | 2008-10-16 | 2008-11-27 |  | 2008-10-16 | 2008-11-27 | 5.25d | 0d |  | Calendario de clase |  | 38h |
| 11 | 3.1 | **realización del prototipo en wrapping** | 3.75d | 2008-10-16 | 2008-11-13 |  | 2008-10-16 | 2008-11-13 | 3.75d | 0d |  | Calendario de clase |  | 26h |
| 12 | 3.1.1 | diseño del sistema | 8h | 2008-10-16 | 2008-10-23 | 6 | 2008-10-16 | 2008-10-23 | 8h | 0d |  | Calendario de clase | técnico DPE | 8h |
| 13 | 3.1.2 | montaje | 2h | 2008-10-23 | 2008-10-23 | 12 | 2008-10-23 | 2008-10-28 | 2h | 0.5d | 0d | Calendario de clase | técnico DPE; laboratorio | 2h |
| 14 | 3.1.3 | pruebas del circuito básico | 2h | 2008-10-28 | 2008-10-28 | 13 | 2008-10-28 | 2008-10-28 | 2h | 0.5d | 0d | Calendario de clase | técnico DPE; laboratorio | 2h |
| 15 | 3.1.4 | pruebas de pulsadores | 3h | 2008-10-28 | 2008-10-30 | 14 | 2008-10-28 | 2008-10-30 | 3h | 0.5d | 0d | Calendario de clase | técnico DPE; laboratorio | 3h |
| 16 | 3.1.5 | pruebas del bloque de entrada | 3h | 2008-10-30 | 2008-11-04 | 15 | 2008-10-30 | 2008-11-04 | 3h | 0.5d | 0d | Calendario de clase | técnico DPE; laboratorio | 3h |
| 17 | 3.1.6 | pruebas de medición de la señal | 4h | 2008-11-04 | 2008-11-06 | 16, 27 | 2008-11-04 | 2008-11-06 | 4h | 0.5d |  | Calendario de clase | técnico DPE; laboratorio | 4h |
| 18 | 3.1.7 | pruebas globales | 4h | 2008-11-11 | 2008-11-13 | 17, 28 | 2008-11-11 | 2008-11-13 | 4h | 0d |  | Calendario de clase | técnico DPE; laboratorio | 4h |
| 19 | 3.2 | **realización del circuito impreso** | 1.5d | 2008-11-13 | 2008-11-27 |  | 2008-11-18 | 2008-11-27 | 1.5d | 0d |  | Calendario de clase |  | 12h |
| 20 | 3.2.1 | diseño de la placa | 4h | 2008-11-13 | 2008-11-18 | 28, 18 | 2008-11-18 | 2008-11-20 | 4h | 0d |  | Calendario de clase | técnico DPE | 4h |
| 21 | 3.2.2 | realización de la placa | 2h | 2008-11-18 | 2008-11-20 | 20 | 2008-11-20 | 2008-11-20 | 2h | 1.25d | 0d | Calendario de clase | técnico DPE; laboratorio | 2h |
| 22 | 3.2.3 | comprobación de la placa | 1h | 2008-11-20 | 2008-11-20 | 21 | 2008-11-20 | 2008-11-20 | 1h | 1.25d | 0d | Calendario de clase | técnico DPE; laboratorio | 1h |
| 23 | 3.2.4 | montaje de componentes | 1h | 2008-11-20 | 2008-11-20 | 22 | 2008-11-25 | 2008-11-25 | 1h | 1.25d | 0d | Calendario de clase | técnico DPE; laboratorio | 1h |
| 24 | 3.2.5 | pruebas de la placa | 4h | 2008-11-25 | 2008-11-27 | 23 | 2008-11-25 | 2008-11-27 | 4h | 1.25d |  | Calendario de clase | técnico DPE; laboratorio | 4h |

| ID | WBS | Task | Duration | Start | Finish | Predecessors | Baseline start | Baseline finish | Baseline duration | Total slack | Calendar | Resources | Work |
| --- | --- | --- | --- | --- | --- | --- | --- | --- | --- | --- | --- | --- | --- |
| 25 | 4 | **realización del software** | 2.25d | 2008-10-23 | 2008-11-11 |  | 2008-10-23 | 2008-11-11 | 2.25d | 0d | Calendario de clase |  | 18h |
| 26 | 4.1 | diseño de alto nivel | 2h | 2008-10-23 | 2008-10-23 | 12, 5 | 2008-10-23 | 2008-10-28 | 2h | 0d | Calendario de clase | técnico DPE | 2h |
| 27 | 4.2 | rutinas de medición de la señal | 8h | 2008-10-28 | 2008-11-04 | 26 | 2008-10-28 | 2008-11-04 | 8h | 0d | Calendario de clase | técnico DPE | 8h |
| 28 | 4.3 | ensamblaje y simulación | 8h | 2008-11-04 | 2008-11-11 | 27 | 2008-11-04 | 2008-11-11 | 8h | 0d | Calendario de clase | técnico DPE; laboratorio | 8h |
| 29 | 5 | **realización de la documentación** | 2.25d | 2008-11-18 | 2008-12-04 |  | 2008-11-20 | 2008-12-09 | 2.25d | 0d | Calendario de clase |  | 20h |
| 30 | 5.1 | memoria descriptiva | 6h | 2008-11-18 | 2008-11-25 | 20, 28 | 2008-11-20 | 2008-11-25 | 6h | 0d | Calendario de clase | técnico DPE | 6h |
| 31 | 5.2 | diseño de hardware | 4h | 2008-11-25 | 2008-11-27 | 30 | 2008-11-25 | 2008-11-27 | 4h | 0d | Calendario de clase | técnico DPE | 4h |
| 32 | 5.3 | diseño de software | 4h | 2008-11-27 | 2008-12-02 | 31 | 2008-12-02 | 2008-12-04 | 4h | 0d | Calendario de clase | técnico DPE | 4h |
| 33 | 5.4 | planos | 1h | 2008-11-27 | 2008-11-27 | 31 | 2008-12-02 | 2008-12-02 | 1h | 0.88d | Calendario de clase | técnico DPE | 1h |
| 34 | 5.5 | presupesto | 1h | 2008-12-02 | 2008-12-04 | 31, 32 | 2008-12-04 | 2008-12-04 | 1h | 0.38d | Calendario de clase | técnico DPE | 1h |
| 35 | 5.6 | manual del usuario | 2h | 2008-12-04 | 2008-12-04 | 36 | 2008-12-04 | 2008-12-09 | 2h | 0d | Calendario de clase | técnico DPE | 2h |
| 36 | 5.7 | manual del S.A.T. | 2h | 2008-12-02 | 2008-12-04 | 31, 32 | 2008-12-04 | 2008-12-04 | 2h | 0d | Calendario de clase | técnico DPE | 2h |
